# managed vpn project2

Schedule from MS Project, 2015-10-01 to 2016-05-11.
Province of British Columbia

## Calendars

- Standard: Mon-Fri 08:00-12:00, 13:00-17:00; Sat-Sun off.

## Schedule

| ID | WBS | Task | Duration | Start | Finish | Predecessors | Total slack | Free slack | Constraint |
| --- | --- | --- | --- | --- | --- | --- | --- | --- | --- |
| 1 | 1 | **Initiation** | 50d? | 2015-10-01 | 2015-12-09 |  | 110d |  |  |
| 2 | 1.1 | **Service Need Identified** | 1d | 2015-10-01 | 2015-10-01 |  | 159d |  |  |
| 3 | 1.1.1 | List services being requested | 1h | 2015-10-01 | 2015-10-01 |  | 159.88d |  | start no earlier than 2015-10-01 |
| 4 | 1.1.2 | Expected business outcome | 1h | 2015-10-01 | 2015-10-01 |  | 159.88d |  | start no earlier than 2015-10-01 |
| 5 | 1.1.3 | List stakeholders impacted | 1h | 2015-10-01 | 2015-10-01 |  | 159.88d |  | start no earlier than 2015-10-01 |
| 6 | 1.1.4 | Identify Sponsor, Business & technical leads | 1h | 2015-10-01 | 2015-10-01 |  | 159.88d |  | start no earlier than 2015-10-01 |
| 7 | 1.1.5 | timeline for implementing the solution | 1h | 2015-10-01 | 2015-10-01 |  | 159.88d |  | start no earlier than 2015-10-01 |
| 8 | 1.1.6 | Submit signed form to AO | 1h | 2015-10-01 | 2015-10-01 |  | 159.88d |  | start no earlier than 2015-10-01 |
| 9 | 1.1.7 | Service Addition Request Form | 1d | 2015-10-01 | 2015-10-01 |  | 159d |  | start no earlier than 2015-10-01 |
| 10 | 1.2 | **Joint Kick Off** | 1.25d | 2015-10-09 | 2015-10-12 |  | 152.75d |  |  |
| 11 | 1.2.1 | Joint Kick Off meeting | 0.5d | 2015-10-09 | 2015-10-09 |  | 153.5d |  | start no earlier than 2015-10-09 |
| 12 | 1.2.2 | Joint Kick Off checklist | 1h | 2015-10-09 | 2015-10-09 |  | 153.88d |  | start no earlier than 2015-10-09 |
| 13 | 1.2.3 | Service Negotiation Project Plan | 2h | 2015-10-09 | 2015-10-09 |  | 153.75d |  | start no earlier than 2015-10-09 |
| 14 | 1.2.4 | Checklist for TSMA Available Services | 2h | 2015-10-12 | 2015-10-12 |  | 152.75d |  | start no earlier than 2015-10-12 |
| 15 | 1.3 | **Province Position defined** | 34d? | 2015-10-23 | 2015-12-09 |  | 110d |  |  |
| 16 | 1.3.1 | Review NOI to confirm TSMA fit | 1d | 2015-10-23 | 2015-10-23 |  | 142d | 0d |  |
| 17 | 1.3.2 | GPS and/or core Mandate | 1d? | 2015-10-23 | 2015-10-23 |  | 143d |  |  |
| 18 | 1.3.3 | Develop and sign Term Sheet | 6d | 2015-12-02 | 2015-12-09 |  | 110d |  | finish no earlier than 2015-12-09 |
| 19 | 1.3.4 | **Complete" TSMA Schedules Target Dates & Responsibilities" Document** | 1d? | 2015-10-23 | 2015-10-23 |  | 143d |  |  |
| 20 | 1.3.4.1 | Identify Schdules that are required to be developed | 1d? | 2015-10-23 | 2015-10-23 |  | 143d |  |  |
| 21 | 1.3.4.2 | Assign responsibilities and due date for individual schedule completion | 1d? | 2015-10-23 | 2015-10-23 |  | 143d |  |  |
| 22 | 1.4 | **Initiate change Request** | 1d? | 2015-10-26 | 2015-10-26 | 16 | 142d |  |  |
| 23 | 1.4.1 | Obtain TSMA change # | 1h | 2015-10-26 | 2015-10-26 |  | 142.88d |  |  |
| 24 | 1.4.2 | Maintain Negotiations Log & Priorotize | 1h | 2015-10-26 | 2015-10-26 |  | 142.88d |  |  |
| 25 | 1.4.3 | Begin negotiations activity planning & establish onboarding mgmt team | 1d | 2015-10-26 | 2015-10-26 |  | 142d |  | start no earlier than 2015-10-06 |
| 26 | 1.4.4 | Prepare framework for required additions/changes to TSMA documentation | 1d? | 2015-10-26 | 2015-10-26 |  | 142d |  |  |
| 27 | 1.4.5 | Complete Change request | 1d? | 2015-10-26 | 2015-10-26 |  | 142d |  | start no earlier than 2015-10-09 |
| 28 | 1.4.6 | NCCS Lead confirms requirements via signature | 1d? | 2015-10-26 | 2015-10-26 |  | 142d |  | start no earlier than 2015-10-09 |
| 29 | 1.4.7 | Stakeholders identified | 1d? | 2015-10-26 | 2015-10-26 |  | 142d |  | start no earlier than 2015-10-09 |
| 30 | 1.4.8 | Charter w scope | 1d? | 2015-10-26 | 2015-10-26 |  | 142d |  | start no earlier than 2015-10-09 |

| ID | WBS | Task | Duration | Start | Finish | Predecessors | Total slack | Free slack | Constraint |
| --- | --- | --- | --- | --- | --- | --- | --- | --- | --- |
| 31 | 2 | **Proposal Development** | 55.5d? | 2015-10-23 | 2016-01-08 |  | 38.75d |  |  |
| 32 | 2.1 | **Kick Off Joint Solutioning Discussions** | 6.12d? | 2015-10-23 | 2015-11-02 |  | 137.88d |  |  |
| 33 | 2.1.1 | Joint Issues & Action Log | 2h | 2015-10-23 | 2015-10-23 |  | 143.75d |  |  |
| 34 | 2.1.2 | Internal Opinion & Decisions Log | 2h | 2015-10-23 | 2015-10-23 |  | 143.75d |  |  |
| 35 | 2.1.3 | Security Discussions (Schedule R) complete | 1d? | 2015-10-30 | 2015-10-30 |  | 137.88d | 0d | start no earlier than 2015-10-30 |
| 36 | 2.1.4 | Telus confirms understanding of requirements | 1h | 2015-11-02 | 2015-11-02 | 35 | 137.88d |  |  |
| 37 | 2.2 | **Solution Identified/Change Proposal** | 48d | 2015-10-23 | 2015-12-29 |  | 38.75d |  |  |
| 38 | 2.2.1 | Telus obtains legal review | 6d | 2015-10-23 | 2015-10-30 |  | 138d |  |  |
| 39 | 2.2.2 | Telus obtainprivacy impact assessment (PIA)s | 19d | 2015-10-23 | 2015-11-18 |  | 125d |  |  |
| 40 | 2.2.3 | Telus obtains security threat risk assessment (STRA) | 19d | 2015-10-23 | 2015-11-18 |  | 125d |  |  |
| 41 | 2.2.4 | Completion of Reference Architecture | 30d | 2015-11-02 | 2015-12-11 |  | 108d |  | start no earlier than 2015-11-02 |
| 42 | 2.2.5 | Completion of service description & schedules | 14d | 2015-12-01 | 2015-12-18 |  | 11.75d | 0d | start no earlier than 2015-12-01 |
| 43 | 2.2.6 | Completion of pricing | 7d | 2015-12-21 | 2015-12-29 | 42 | 11.75d | 0d | start no earlier than 2015-10-29 |
| 44 | 2.3 | **Province Response to Telus Proposal** | 7.5d? | 2015-12-30 | 2016-01-08 | 43 | 11.75d |  |  |
| 45 | 2.3.1 | Ensure solution satisfies the business requirements | 1d? | 2016-01-04 | 2016-01-04 |  | 8.75d | 0d | start no earlier than 2016-01-04 |
| 46 | 2.3.2 | Solution satisfies the technical requirements | 1d? | 2016-01-04 | 2016-01-04 |  | 91.5d | 0d | start no earlier than 2016-01-04 |
| 47 | 2.3.3 | Implementation plan is reasonable | 0.5d | 2016-01-05 | 2016-01-05 | 46 | 91.5d |  |  |
| 48 | 2.3.4 | Pricing cost & value review | 7d | 2015-12-30 | 2016-01-07 |  | 89d |  |  |
| 49 | 2.3.5 | Ensure PIA performed | 1h | 2016-01-05 | 2016-01-05 | 45 | 91.88d |  |  |
| 50 | 2.3.6 | Ensure STRA performed | 1h | 2016-01-05 | 2016-01-05 | 45 | 91.88d |  |  |
| 51 | 2.3.7 | Legal review to confirm language reflects requirements | 1d? | 2016-01-05 | 2016-01-05 | 45 | 8.75d | 0d |  |
| 52 | 2.3.8 | AO confirms with NCCS that business and technical requirements have been met | 1d? | 2016-01-06 | 2016-01-06 | 51 | 8.75d | 0d |  |
| 53 | 2.3.9 | Approvals to proceed to contract | 1d? | 2016-01-07 | 2016-01-07 | 52 | 8.75d | 0d |  |
| 54 | 2.3.10 | AO to notify Telus that documents are ready to be submitted in final | 0.5d | 2016-01-08 | 2016-01-08 | 53 | 8.75d | 0d |  |

| ID | WBS | Task | Duration | Start | Finish | Predecessors | Total slack | Free slack | Constraint |
| --- | --- | --- | --- | --- | --- | --- | --- | --- | --- |
| 55 | 3 | **Proposal Acceptance** | 88.5d? | 2016-01-08 | 2016-05-11 | 54 | 0d |  |  |
| 56 | 3.1 | **Solution Accepted** | 88.5d? | 2016-01-08 | 2016-05-11 |  | 0d |  |  |
| 57 | 3.1.1 | Telus to prepare final proposal and submit formally to AO | 1d? | 2016-01-08 | 2016-01-11 |  | 8.75d | 0d |  |
| 58 | 3.1.2 | AO to review final documents to ensure alignment with the contract prior to AO signing | 2d | 2016-01-11 | 2016-01-13 | 57 | 8.75d | 0d |  |
| 59 | 3.1.3 | Confirm with NCCS lead | 1h | 2016-01-13 | 2016-01-13 | 58 | 8.75d | 0d |  |
| 60 | 3.1.4 | Administrator signature | 1h | 2016-01-13 | 2016-01-13 | 59 | 8.75d | 0d |  |
| 61 | 3.1.5 | Change Order | 0.5d | 2016-01-13 | 2016-01-14 | 60 | 8.75d | 0d | start no earlier than 2016-01-13 |
| 62 | 3.1.6 | **Performance & Control** | 81d | 2016-01-20 | 2016-05-11 |  | 0d |  |  |
| 63 | 3.1.6.1 | **Status reports** | 81d | 2016-01-20 | 2016-05-11 |  | 0d |  |  |
| 64 | 3.1.6.1.1 | Status reports 1 | 1d | 2016-01-20 | 2016-01-20 |  | 80d |  | start no earlier than 2016-01-20 |
| 65 | 3.1.6.1.2 | Status reports 2 | 1d | 2016-01-27 | 2016-01-27 |  | 75d |  | start no earlier than 2016-01-27 |
| 66 | 3.1.6.1.3 | Status reports 3 | 1d | 2016-02-03 | 2016-02-03 |  | 70d |  | start no earlier than 2016-02-03 |
| 67 | 3.1.6.1.4 | Status reports 4 | 1d | 2016-02-10 | 2016-02-10 |  | 65d |  | start no earlier than 2016-02-10 |
| 68 | 3.1.6.1.5 | Status reports 5 | 1d | 2016-02-17 | 2016-02-17 |  | 60d |  | start no earlier than 2016-02-17 |
| 69 | 3.1.6.1.6 | Status reports 6 | 1d | 2016-02-24 | 2016-02-24 |  | 55d |  | start no earlier than 2016-02-24 |
| 70 | 3.1.6.1.7 | Status reports 7 | 1d | 2016-03-02 | 2016-03-02 |  | 50d |  | start no earlier than 2016-03-02 |
| 71 | 3.1.6.1.8 | Status reports 8 | 1d | 2016-03-09 | 2016-03-09 |  | 45d |  | start no earlier than 2016-03-09 |
| 72 | 3.1.6.1.9 | Status reports 9 | 1d | 2016-03-16 | 2016-03-16 |  | 40d |  | start no earlier than 2016-03-16 |
| 73 | 3.1.6.1.10 | Status reports 10 | 1d | 2016-03-23 | 2016-03-23 |  | 35d |  | start no earlier than 2016-03-23 |
| 74 | 3.1.6.1.11 | Status reports 11 | 1d | 2016-03-30 | 2016-03-30 |  | 30d |  | start no earlier than 2016-03-30 |
| 75 | 3.1.6.1.12 | Status reports 12 | 1d | 2016-04-06 | 2016-04-06 |  | 25d |  | start no earlier than 2016-04-06 |
| 76 | 3.1.6.1.13 | Status reports 13 | 1d | 2016-04-13 | 2016-04-13 |  | 20d |  | start no earlier than 2016-04-13 |
| 77 | 3.1.6.1.14 | Status reports 14 | 1d | 2016-04-20 | 2016-04-20 |  | 15d |  | start no earlier than 2016-04-20 |
| 78 | 3.1.6.1.15 | Status reports 15 | 1d | 2016-04-27 | 2016-04-27 |  | 10d |  | start no earlier than 2016-04-27 |
| 79 | 3.1.6.1.16 | Status reports 16 | 1d | 2016-05-04 | 2016-05-04 |  | 5d |  | start no earlier than 2016-05-04 |
| 80 | 3.1.6.1.17 | Status reports 17 | 1d | 2016-05-11 | 2016-05-11 |  | 0d |  | start no earlier than 2016-05-11 |
| 81 | 3.1.7 | Notify stakeholders of the change | 1d? | 2016-01-08 | 2016-01-11 |  | 87.5d |  |  |
| 82 | 3.1.8 | AO maintains TSMA Living Contract sharepoint site | 49d | 2016-01-08 | 2016-03-17 |  | 39.5d |  |  |

| ID | WBS | Task | Duration | Start | Finish | Predecessors | Total slack | Free slack | Constraint |
| --- | --- | --- | --- | --- | --- | --- | --- | --- | --- |
| 83 | 3.2 | **Close Out** | 0.5d | 2016-01-15 | 2016-01-15 |  | 83.5d |  |  |
| 84 | 3.2.1 | Internal Close Out report | 0.5d | 2016-01-15 | 2016-01-15 |  | 83.5d |  | start no earlier than 2016-01-15 |
| 85 | 4 | **Execution** | 75d? | 2016-01-14 | 2016-04-28 |  | 8.75d |  |  |
| 86 | 4.1 | Service Order | 1d? | 2016-01-14 | 2016-01-15 | 61 | 8.75d | 0d |  |
| 87 | 4.2 | Complete pilot of VPN service | 54d | 2016-01-15 | 2016-03-31 | 86 | 8.75d | 0d |  |
| 88 | 4.3 | Complete build of production environment | 20d | 2016-03-31 | 2016-04-28 | 87 | 8.75d | 0.75d |  |
| 89 | 5 | **Project Close** | 6d? | 2016-04-29 | 2016-05-06 | 88 | 3d |  |  |
| 90 | 5.1 | Highlight Success | 1d? | 2016-04-29 | 2016-04-29 |  | 8d |  | start no earlier than 2016-04-29 |
| 91 | 5.2 | Lessons learned | 1d? | 2016-05-06 | 2016-05-06 |  | 3d |  | start no earlier than 2016-05-06 |
